# OPERADOR DE CANTERAS DE ROCA - RÍO VIRÚ - copia recursos s10

Schedule from Primavera P6, 2025-05-12 to 2026-08-25, data date 2025-05-12.
Must finish by 2026-08-24

## Calendars

- OHLA RIOS: Mon-Sun 07:00-17:00.

## Resources

| Resource | Group |
| --- | --- |
| RODILLO LISO VIBRATORIO AUTOPROPULSADO 10-12 ton | equipment |
| EXCAVADORA CAT 336 | equipment |
| TRACTOR SOBRE ORUGAS CAT D8T | equipment |
| TRACTOR SOBRE ORUGAS CAT D6T | equipment |
| MARTILLO HIDRAULICO P/EXCAVADORA | equipment |
| TRACK DRILL | equipment |
| CAMIÓN VOLQUETE DE 20 m3 PARA ROCA | equipment |
| MARTILLO NEUMATICO DE 25 - 29 kg | equipment |
| Explotacion de cantera | material |
| ROCK DRILL 2.5" | equipment |

## Schedule

| ID | WBS | Activity | Duration | Start | Finish | Predecessors | Total float | Free float | Resources |
| --- | --- | --- | --- | --- | --- | --- | --- | --- | --- |
|  | 0 | **HITOS** |  | 2025-05-12 | 2026-08-25 |  |  |  |  |
| A1010 |  | Inicio de Plazo Contractual - Acceso al Sitio | 0d | 2025-05-12 | 2025-05-12 |  | -0.1d | 0d |  |
| A1030 |  | Inicio de Movilizacion | 0d | 2025-05-12 | 2025-05-12 | A1010 SS | -0.1d | 0d |  |
| A1040 |  | Inicio de Explotacion de Canteras | 0d | 2025-08-01 | 2025-08-01 | A4050 SS | 388.9d | 389d |  |
| A1020 |  | Fin de Plazo Contractual - Culminacion de Obras | 0d | 2026-08-25 | 2026-08-25 | A1280 | -0.1d | 0d |  |
|  | 1 | **OBRAS PRELIMINARES** |  | 2025-05-12 | 2025-06-10 |  |  |  |  |
|  | 1 | **TRAMITES** |  | 2025-05-12 | 2025-06-10 |  |  |  |  |
| A1050 |  | Tramite, gestión y obtención de permisos para uso y adquisición de explosivos | 30d | 2025-05-12 | 2025-06-10 | A1010 SS | 50.9d | 51d |  |
| A1060 |  | Tramite, gestión y obtención de permisos para manipulación de explosivos | 30d | 2025-05-12 | 2025-06-10 | A1010 SS | 178.9d | 61d |  |
| A1070 |  | Tramite, gestión y obtención de permisos para almacenamiento y uso de polvorín | 30d | 2025-05-12 | 2025-06-10 | A1010 SS | 178.9d | 61d |  |
| A1080 |  | Tramite, gestión y obtención de permisos para explotación de canteras | 30d | 2025-05-12 | 2025-06-10 | A1010 SS | 178.9d | 61d |  |
|  | 3 | **OBRAS POVISIONALES** |  | 2025-05-12 | 2026-08-24 |  |  |  |  |
|  | 2 | **MOVILIZACIONES** |  | 2025-05-12 | 2026-08-24 |  |  |  |  |
| A1270 |  | Movilización de equipos a obra | 30d | 2025-05-12 | 2025-06-10 | A1030 SS | -0.1d | 0d |  |
| A1280 |  | Desmovilización de equipos de obra | 16d | 2026-08-09 | 2026-08-24 | A1110, A3950, A3850, A4000, A4050, A2280, A2290, A2220, A2380, A2450, A2470, A2420, A2500, A2510, A3310, A3320, A3260, A3480, A3500, A3510, A4030, A4040, A4020, A2960, A3030, A2990, A3020, A3050, A3060, A3720, A3730, A3930, A3890, A3970, A3980, A3750, A3690, A2700, A3860, A4190, A3870, A3940, A4140, A4110, A2970, A4130, A3530, A3610, A4070 | -0.1d | 0d |  |
|  | 8 | **TRAZO Y REPLANTEO** |  | 2025-05-22 | 2026-08-07 |  |  |  |  |
| A1090 |  | Trazo y replanteo topográfico al inicio de obra | 15d | 2025-05-22 | 2025-06-05 | A1270 SS+10d | 0.9d | 0d |  |
| A1100 |  | Trazo y replanteo topográfico durante la ejecución de la obra | 421d | 2025-06-06 | 2026-07-31 | A1090 | 0.9d | 0d |  |
| A1110 |  | Levantamiento Topográfico final de obra | 7d | 2026-08-01 | 2026-08-07 | A1100 | 0.9d | 1d |  |
|  | 6 | **CONSTRUCCION DE INSTALACION DE POLVORIN** |  | 2025-06-01 | 2025-07-01 |  |  |  |  |
| A1320 |  | Desbroce y remoción de suelo vegetal con equipo | 1d | 2025-06-01 | 2025-06-01 | A1090 SS+10d | 33.9d | 0d | EXCAVADORA CAT 336 [0.43 h]; TRACTOR SOBRE ORUGAS CAT D8T [0.43 h] |
| A1310 |  | Excavación de material común | 2d | 2025-06-02 | 2025-06-03 | A1320 | 33.9d | 0d |  |
| A1330 |  | Conformación de material excedente en DMO | 1d | 2025-06-02 | 2025-06-02 | A1320 | 34.9d | 1d |  |
| A1340 |  | Conformación de material excedente en DME | 2d | 2025-06-02 | 2025-06-03 | A1320 | 33.9d | 0d |  |
| A1290 |  | Conformación de terraplén para polvorin | 8d | 2025-06-04 | 2025-06-11 | A1320, A1310, A1330, A1340 | 33.9d | 0d | RODILLO LISO VIBRATORIO AUTOPROPULSADO 10-12 ton [60.3 h]; EXCAVADORA CAT 336 [76.5 h]; TRACTOR SOBRE ORUGAS CAT D8T [13.5 h] |
| A1300 |  | Construcción e implementacion de polvorin | 20d | 2025-06-12 | 2025-07-01 | A1290 | 33.9d | 25d | RODILLO LISO VIBRATORIO AUTOPROPULSADO 10-12 ton [40.5 h]; TRACTOR SOBRE ORUGAS CAT D6T [40.5 h] |

| ID | WBS | Activity | Duration | Start | Finish | Predecessors | Total float | Free float | Resources |
| --- | --- | --- | --- | --- | --- | --- | --- | --- | --- |
|  | 1 | **REHABILITACION DE ACCESOS** |  | 2025-06-01 | 2026-08-06 |  |  |  |  |
| A3990 |  | Rehabilitación de accesos existentes | 15d | 2025-06-01 | 2025-06-15 | A1270 SS+20d | -0.1d | 0d | RODILLO LISO VIBRATORIO AUTOPROPULSADO 10-12 ton [107.25 h]; EXCAVADORA CAT 336 [132 h] |
| A4000 |  | Mantenimiento de accesos (L = 2km) | 417d | 2025-06-16 | 2026-08-06 | A3990 | 1.9d | 2d | RODILLO LISO VIBRATORIO AUTOPROPULSADO 10-12 ton [409.64 h] |
| A4070 |  | Desbroce y remoción de suelo vegetal con equipo en DME Y DMO | 182d | 2025-06-16 | 2025-12-14 | A3990 | 236.9d | 237d |  |
|  | 2 | **EXPLOTACION DE CANTERAS** |  | 2025-05-12 | 2026-08-08 |  |  |  |  |
|  | 1 | **CANTERA CERRO BLANCO 1-2** |  | 2025-06-16 | 2026-07-02 |  |  |  |  |
|  | 4 | **OBRAS PRELIMINARES** |  | 2025-06-16 | 2026-07-02 |  |  |  |  |
|  | 1 | **Construccion de acceso nuevo** |  | 2025-06-16 | 2025-07-26 |  |  |  |  |
| A2020 |  | Desbroce y remoción de suelo vegetal con equipo | 1d | 2025-06-16 | 2025-06-16 | A3990 | 8.9d | 0d | EXCAVADORA CAT 336 [2.57 h]; TRACTOR SOBRE ORUGAS CAT D6T [2.57 h] |
| A2050 |  | Excavación en material común | 9d | 2025-06-17 | 2025-06-25 | A2020 | 8.9d | 0d | EXCAVADORA CAT 336 [66 h]; TRACTOR SOBRE ORUGAS CAT D8T [33 h] |
| A2100 |  | Conformación de material excedente en DMO | 1d | 2025-06-17 | 2025-06-17 | A2020 | 28.9d | 2d |  |
| A2090 |  | Proceso y selección de material propio | 6d | 2025-06-20 | 2025-06-25 | A2050 SS+3d, A2100 | 26.9d | 18d | EXCAVADORA CAT 336 [48.96 h] |
| A2060 |  | Excavación en roca fracturada | 2d | 2025-06-26 | 2025-06-27 | A2050 | 8.9d | 0d | EXCAVADORA CAT 336 [5.98 h]; MARTILLO HIDRAULICO P/EXCAVADORA [5.98 h]; TRACTOR SOBRE ORUGAS CAT D8T [11.96 h] |
| A2070 |  | Excavación en roca fija con martillo hidráulico | 24d | 2025-06-26 | 2025-07-19 | A2060 SS | 8.9d | 0d | EXCAVADORA CAT 336 [194.12 h]; MARTILLO HIDRAULICO P/EXCAVADORA [194.12 h] |
| A2110 |  | Conformación de material excedente en DME | 5d | 2025-06-26 | 2025-06-30 | A2050 | 27.9d | 19d |  |
| A2080 |  | Relleno compactado con equipo pesado para accesos | 7d | 2025-07-20 | 2025-07-26 | A2090 FS+6d, A2070, A2110 | 8.9d | 0d | RODILLO LISO VIBRATORIO AUTOPROPULSADO 10-12 ton [52.64 h] |
|  | 2 | **Conformación de plataforma para zonas de acopio** |  | 2025-07-20 | 2025-08-22 |  |  |  |  |
| A2140 |  | Desbroce y remoción de suelo vegetal con equipo | 2d | 2025-07-20 | 2025-07-21 | A2070 | 46.9d | 0d | EXCAVADORA CAT 336 [9.24 h]; TRACTOR SOBRE ORUGAS CAT D6T [9.24 h] |
| A2160 |  | Excavación en material común | 15d | 2025-07-22 | 2025-08-05 | A2140 | 46.9d | 0d | EXCAVADORA CAT 336 [74.53 h]; TRACTOR SOBRE ORUGAS CAT D8T [37.27 h] |
| A2250 |  | Conformación de material excedente en DMO | 1d | 2025-07-22 | 2025-07-22 | A2140 | 59.9d | 0d |  |
| A2260 |  | Conformación de material excedente en DME | 15d | 2025-07-23 | 2025-08-06 | A2160 SS, A2250 | 59.9d | 13d |  |
| A2240 |  | Proceso y selección de material propio | 10d | 2025-07-27 | 2025-08-05 | A2160 FF | 46.9d | 0d |  |
| A2170 |  | Relleno compactado con equipo pesado para plataforma de acopio | 6d | 2025-08-06 | 2025-08-11 | A2160, A2240 | 46.9d | 0d | RODILLO LISO VIBRATORIO AUTOPROPULSADO 10-12 ton [127.01 h]; TRACTOR SOBRE ORUGAS CAT D8T [127.01 h] |
| A2180 |  | Suministro, construcción e instalación de cerco perímetrico | 8d | 2025-08-12 | 2025-08-19 | A2170 | 46.9d | 0d |  |
| A2190 |  | Suministro, construcción e instalación de garita de control de ingreso y salida | 3d | 2025-08-20 | 2025-08-22 | A2180, A2260 | 46.9d | 10d |  |

| ID | WBS | Activity | Duration | Start | Finish | Predecessors | Total float | Free float | Resources |
| --- | --- | --- | --- | --- | --- | --- | --- | --- | --- |
|  | 3 | **Construcción de campamentos/oficinas** |  | 2025-07-22 | 2025-09-01 |  |  |  |  |
| A2270 |  | Desbroce y remoción de suelo vegetal con equipo en DME | 1d | 2025-07-22 | 2025-07-22 | A2140 | 48.9d | 0d |  |
| A2230 |  | Desbroce y remoción de suelo vegetal con equipo | 1d | 2025-07-23 | 2025-07-23 | A2270 | 48.9d | 12d | EXCAVADORA CAT 336 [0.21 h]; TRACTOR SOBRE ORUGAS CAT D8T [0.21 h] |
| A2320 |  | Conformación de material excedente en DMO | 1d | 2025-07-23 | 2025-07-23 | A2270 | 48.9d | 12d |  |
| A2200 |  | Conformación de terraplén para campamentos | 8d | 2025-08-05 | 2025-08-12 | A2230, A2320, A3910 | 36.9d | 0d | RODILLO LISO VIBRATORIO AUTOPROPULSADO 10-12 ton [27.6 h]; EXCAVADORA CAT 336 [35.02 h]; TRACTOR SOBRE ORUGAS CAT D8T [6.18 h] |
| A2210 |  | Construcción de campamentos | 15d | 2025-08-13 | 2025-08-27 | A2200 | 36.9d | 0d |  |
| A2300 |  | Restauración y revegetación de áreas intervenidas | 5d | 2025-08-28 | 2025-09-01 | A2210 | 36.9d | 0d | EXCAVADORA CAT 336 [8.12 h]; TRACTOR SOBRE ORUGAS CAT D6T [9.83 h] |
|  | 4 | **Controles** |  | 2025-06-17 | 2026-07-02 |  |  |  |  |
| A2280 |  | Señalización de obra | 371d | 2025-06-17 | 2026-06-22 | A2020 | 46.9d | 47d |  |
| A2290 |  | Implementación de controles ambientales durante la construcción | 371d | 2025-06-17 | 2026-06-22 | A2020 | 46.9d | 47d |  |
| A2220 |  | Mantenimiento de campamentos | 304d | 2025-09-02 | 2026-07-02 | A2300, A2190 | 36.9d | 37d |  |
|  | 5 | **EXPLOTACION DE CANTERA** |  | 2025-07-27 | 2026-06-22 |  |  |  |  |
|  | 1 | **Habilitacion de Cantera** |  | 2025-07-27 | 2025-08-29 |  |  |  |  |
| A2310 |  | Desbroce y remoción de suelo vegetal con equipo | 2d | 2025-07-27 | 2025-07-28 | A2080, A1300 | 8.9d | 0d | EXCAVADORA CAT 336 [16.71 h]; TRACTOR SOBRE ORUGAS CAT D6T [16.71 h] |
| A2360 |  | Perforación manual y voladura (habilitación de área de perforación para Rockdrill) | 11d | 2025-07-29 | 2025-08-08 | A2310 | 8.9d | 0d | EXCAVADORA CAT 336 [30.97 h]; TRACK DRILL [86.68 h] |
| A2390 |  | Conformación de material excedente en DMO | 2d | 2025-07-29 | 2025-07-30 | A2310 | 17.9d | 9d |  |
| A2340 |  | Excavación en material suelto | 4d | 2025-08-09 | 2025-08-12 | A2360, A2390 | 8.9d | 0d | EXCAVADORA CAT 336 [26.95 h]; TRACTOR SOBRE ORUGAS CAT D8T [13.48 h] |
| A2350 |  | Excavación en roca fracturada | 17d | 2025-08-13 | 2025-08-29 | A2340 | 8.9d | 0d | EXCAVADORA CAT 336 [69.18 h]; MARTILLO HIDRAULICO P/EXCAVADORA [69.18 h]; TRACTOR SOBRE ORUGAS CAT D8T [138.35 h] |
| A2380 |  | Conformación de material excedente en DME | 17d | 2025-08-13 | 2025-08-29 | A2340 SS+4d | 343.9d | 344d | EXCAVADORA CAT 336 [15.97 h]; TRACTOR SOBRE ORUGAS CAT D6T [103.8 h] |
|  | 2 | **Producción material en cantera de cerro (macizo rocoso)** |  | 2025-08-30 | 2026-06-22 |  |  |  |  |
|  | 1 | **Produccion de Roca** |  | 2025-08-30 | 2026-06-10 |  |  |  |  |
| A2530 |  | Perforación y voladura de roca con Fr de 45% | 248d | 2025-08-30 | 2026-05-04 | A2350 | 8.9d | 0d |  |
| A2410 |  | Remoción y limpieza de material perforado y volado en cantera | 274d | 2025-09-01 | 2026-06-01 | A2530 SS+2d | 8.9d | 0d | Explotacion de cantera [490113]; EXCAVADORA CAT 336 [10145.3 h]; TRACTOR SOBRE ORUGAS CAT D6T [1911.44 h]; CAMIÓN VOLQUETE DE 20 m3 PARA ROCA [5244.21 h]; MARTILLO HIDRAULICO P/EXCAVADORA [3381.78 h]; ROCK DRILL 2.5" [4509.04 h] |
| A2430 |  | Selección de material para enrocado | 278d | 2025-09-06 | 2026-06-10 | A2410 SS+5d | 46.9d | 0d |  |
| A2400 |  | Fracturación y selección de roca para rip rap | 2d | 2025-09-07 | 2025-09-08 | A2360, A2410 SS+6d | 11.9d | 0d | EXCAVADORA CAT 336 [22.06 h]; TRACTOR SOBRE ORUGAS CAT D6T [1.72 h]; CAMIÓN VOLQUETE DE 20 m3 PARA ROCA [4.72 h]; MARTILLO HIDRAULICO P/EXCAVADORA [15.22 h] |
| A2440 |  | Selección de material para rip rap | 1d | 2025-09-09 | 2025-09-09 | A2530 SS+10d, A2400 | 11.9d | 0d |  |
| A2470 |  | Conformación de material excedente en DME | 247d | 2025-10-07 | 2026-06-10 | A2430 FF | 58.9d | 59d | EXCAVADORA CAT 336 [312.04 h]; TRACTOR SOBRE ORUGAS CAT D6T [2028.27 h] |

| ID | WBS | Activity | Duration | Start | Finish | Predecessors | Total float | Free float | Resources |
| --- | --- | --- | --- | --- | --- | --- | --- | --- | --- |
|  | 2 | **Carguios** |  | 2025-09-14 | 2026-06-22 |  |  |  |  |
| A2450 |  | Carguio de material inadecuado en cantera para eliminación | 270d | 2025-09-14 | 2026-06-10 | A2430 FF | 58.9d | 59d | EXCAVADORA CAT 336 [2137.69 h]; CAMIÓN VOLQUETE DE 20 m3 PARA ROCA [4383.12 h] |
| A2460 |  | Carguío de material seleccionado hacia zona de acopio | 260d | 2025-09-24 | 2026-06-10 | A2530 FF, A2430 FF | 46.9d | 0d |  |
| A2480 |  | Carguío de material acopiado | 255d | 2025-10-03 | 2026-06-14 | A2430 FF+4d | 70.9d | 251d | EXCAVADORA CAT 336 [2796.16 h]; CAMIÓN VOLQUETE DE 20 m3 PARA ROCA [227.86 h] |
| A2420 |  | Carguio de material remanente en acopio para eliminación | 12d | 2026-06-11 | 2026-06-22 | A2480 SS, A2410 FF, A2460, A2430 | 46.9d | 47d | EXCAVADORA CAT 336 [91.18 h]; CAMIÓN VOLQUETE DE 20 m3 PARA ROCA [217.33 h] |
|  | 3 | **IMPLEMENTACIÓN PARA CONTROL Y PESAJE DE ROCA** |  | 2025-08-30 | 2026-06-22 |  |  |  |  |
|  | 1 | **Instalación de sistema de pesaje** |  | 2025-08-30 | 2026-06-22 |  |  |  |  |
| A2490 |  | Suministro, construcción, montaje e instalación de balanza, caseta y tablero de control de pesaje | 10d | 2025-08-30 | 2025-09-08 | A2350 | 46.9d | 0d |  |
| A2500 |  | Operación y control de sistema de pesaje (INC Energia electrica e iluminación de plataforma de acopio y balanza) | 287d | 2025-09-09 | 2026-06-22 | A2490 | 46.9d | 47d |  |
|  | 2 | **Pruebas de control de calidad** |  | 2025-09-09 | 2026-06-22 |  |  |  |  |
| A2510 |  | Ensayos de roca | 287d | 2025-09-09 | 2026-06-22 | A2490 | 46.9d | 47d |  |
|  | 2 | **CANTERA DE CERRO - CARABAMBA 1** |  | 2026-06-02 | 2026-07-30 |  |  |  |  |
|  | 4 | **OBRAS PRELIMINARES** |  | 2026-06-02 | 2026-07-30 |  |  |  |  |
|  | 1 | **Construccion de acceso nuevo** |  | 2026-06-02 | 2026-06-12 |  |  |  |  |
| A3070 |  | Desbroce y remoción de suelo vegetal con equipo | 1d | 2026-06-02 | 2026-06-02 | A2410 | 8.9d | 0d | EXCAVADORA CAT 336 [0.17 h]; TRACTOR SOBRE ORUGAS CAT D6T [0.17 h] |
| A3100 |  | Excavación en material común | 1d | 2026-06-03 | 2026-06-03 | A3070 | 8.9d | 0d | EXCAVADORA CAT 336 [4.3 h]; TRACTOR SOBRE ORUGAS CAT D8T [2.15 h] |
| A3280 |  | Conformación de material excedente en DMO | 1d | 2026-06-03 | 2026-06-03 | A3070 | 20.9d | 0d |  |
| A3110 |  | Excavación en roca fracturada | 1d | 2026-06-04 | 2026-06-04 | A3100 | 8.9d | 0d | EXCAVADORA CAT 336 [0.39 h]; MARTILLO HIDRAULICO P/EXCAVADORA [0.39 h]; TRACTOR SOBRE ORUGAS CAT D8T [0.78 h] |
| A3290 |  | Conformación de material excedente en DME | 1d | 2026-06-04 | 2026-06-04 | A3100, A3280 | 20.9d | 6d |  |
| A3120 |  | Excavación en roca fija con martillo hidráulico | 2d | 2026-06-05 | 2026-06-06 | A3110 | 8.9d | 0d | EXCAVADORA CAT 336 [12.68 h]; MARTILLO HIDRAULICO P/EXCAVADORA [12.68 h] |
| A3140 |  | Proceso y selección de material propio | 1d | 2026-06-07 | 2026-06-07 | A3120 | 8.9d | 0d | EXCAVADORA CAT 336 [3.19 h] |
| A3130 |  | Relleno compactado con equipo pesado para accesos | 1d | 2026-06-08 | 2026-06-08 | A3140 | 8.9d | 0d | RODILLO LISO VIBRATORIO AUTOPROPULSADO 10-12 ton [3.43 h] |
| A3220 |  | Suministro, construcción e instalación de cerco perímetrico | 2d | 2026-06-09 | 2026-06-10 | A3130 | 10.9d | 0d |  |
| A3230 |  | Suministro, construcción e instalación de garita de control de ingreso y salida | 2d | 2026-06-11 | 2026-06-12 | A3220, A3290 | 14.9d | 6d |  |

| ID | WBS | Activity | Duration | Start | Finish | Predecessors | Total float | Free float | Resources |
| --- | --- | --- | --- | --- | --- | --- | --- | --- | --- |
|  | 2 | **Conformación de plataforma para zonas de acopio** |  | 2026-06-11 | 2026-06-26 |  |  |  |  |
| A4060 |  | Desbroce y remoción de suelo vegetal con equipo | 1d | 2026-06-11 | 2026-06-11 | A3220 | 10.9d | 0d | EXCAVADORA CAT 336 [2.39 h]; TRACTOR SOBRE ORUGAS CAT D6T [2.39 h] |
| A3200 |  | Excavación en material común | 3d | 2026-06-12 | 2026-06-14 | A4060 | 10.9d | 0d | EXCAVADORA CAT 336 [19.24 h]; TRACTOR SOBRE ORUGAS CAT D8T [9.62 h] |
| A3380 |  | Conformación de material excedente en DMO | 1d | 2026-06-12 | 2026-06-12 | A4060 | 50.9d | 2d |  |
| A3210 |  | Relleno compactado con equipo pesado para plataforma de acopio | 2d | 2026-06-15 | 2026-06-16 | A3200 | 10.9d | 0d | RODILLO LISO VIBRATORIO AUTOPROPULSADO 10-12 ton [32.79 h]; TRACTOR SOBRE ORUGAS CAT D8T [32.79 h] |
| A3400 |  | Conformación de material excedente en DME | 1d | 2026-06-15 | 2026-06-15 | A3200, A3380 | 48.9d | 6d |  |
| A3370 |  | Proceso y selección de material propio | 2d | 2026-06-17 | 2026-06-18 | A3210 | 45.9d | 3d |  |
| A3410 |  | Suministro, construcción e instalación de cerco perímetrico | 5d | 2026-06-17 | 2026-06-21 | A3210 | 42.9d | 0d |  |
| A3610 |  | Suministro, construcción e instalación de garita de control de ingreso y salida | 5d | 2026-06-22 | 2026-06-26 | A3210, A3400, A3370, A3410 | 42.9d | 43d |  |
|  | 3 | **Construcción de campamentos/oficinas** |  | 2026-06-09 | 2026-06-19 |  |  |  |  |
| A3270 |  | Desbroce y remoción de suelo vegetal con equipo | 1d | 2026-06-09 | 2026-06-09 | A3130 | 8.9d | 0d | EXCAVADORA CAT 336 [0.21 h]; TRACTOR SOBRE ORUGAS CAT D8T [0.21 h] |
| A3240 |  | Conformación de terraplén para campamentos | 4d | 2026-06-10 | 2026-06-13 | A3270 | 8.9d | 0d | RODILLO LISO VIBRATORIO AUTOPROPULSADO 10-12 ton [27.6 h]; EXCAVADORA CAT 336 [35.02 h]; TRACTOR SOBRE ORUGAS CAT D8T [6.18 h] |
| A3300 |  | Desbroce y remoción de suelo vegetal con equipo en DME | 1d | 2026-06-10 | 2026-06-10 | A3270 | 16.9d | 8d |  |
| A4200 |  | Desbroce y remoción de suelo vegetal con equipo en DMO | 1d | 2026-06-10 | 2026-06-10 | A3270 | 11.9d | 3d |  |
| A3250 |  | Construcción de campamentos | 5d | 2026-06-14 | 2026-06-18 | A3240, A4200 | 8.9d | 0d |  |
| A3330 |  | Restauración y revegetación de áreas intervenidas | 1d | 2026-06-19 | 2026-06-19 | A3250 | 8.9d | 0d |  |
|  | 4 | **Controles** |  | 2026-06-04 | 2026-07-30 |  |  |  |  |
| A3310 |  | Señalización de obra | 57d | 2026-06-04 | 2026-07-30 | A3100 | 8.9d | 9d |  |
| A3320 |  | Implementación de controles ambientales durante la construcción | 57d | 2026-06-04 | 2026-07-30 | A3100 | 8.9d | 9d |  |
| A3260 |  | Mantenimiento de campamentos | 42d | 2026-06-19 | 2026-07-30 | A3250, A3230, A3210, A3300 | 8.9d | 9d | EXCAVADORA CAT 336 [2.21 h]; TRACTOR SOBRE ORUGAS CAT D6T [2.68 h] |
|  | 5 | **EXPLOTACION DE CANTERA** |  | 2026-06-20 | 2026-07-30 |  |  |  |  |
|  | 1 | **Habilitacion de Cantera** |  | 2026-06-20 | 2026-06-26 |  |  |  |  |
| A3340 |  | Excavación en material suelto | 4d | 2026-06-20 | 2026-06-23 | A3130, A3330 | 8.9d | 0d | EXCAVADORA CAT 336 [9.68 h]; TRACTOR SOBRE ORUGAS CAT D8T [4.84 h] |
| A3350 |  | Excavación en roca fracturada | 7d | 2026-06-20 | 2026-06-26 | A3340 SS | 8.9d | 0d | EXCAVADORA CAT 336 [24.85 h]; MARTILLO HIDRAULICO P/EXCAVADORA [24.85 h]; TRACTOR SOBRE ORUGAS CAT D8T [49.7 h] |
| A3360 |  | Perforación manual y voladura (habilitación de área de perforación para Rockdrill) | 1d | 2026-06-20 | 2026-06-20 | A3350 SS | 8.9d | 0d | EXCAVADORA CAT 336 [0.36 h]; TRACK DRILL [1.02 h] |
| A3390 |  | Conformación de material excedente en DME | 3d | 2026-06-22 | 2026-06-24 | A3340 SS+2d | 9.9d | 1d | EXCAVADORA CAT 336 [3.66 h]; TRACTOR SOBRE ORUGAS CAT D6T [23.77 h] |

| ID | WBS | Activity | Duration | Start | Finish | Predecessors | Total float | Free float | Resources |
| --- | --- | --- | --- | --- | --- | --- | --- | --- | --- |
|  | 2 | **Producción material en cantera de cerro (macizo rocoso)** |  | 2026-06-26 | 2026-07-30 |  |  |  |  |
|  | 1 | **Produccion de Roca** |  | 2026-06-26 | 2026-07-23 |  |  |  |  |
| A3430 |  | Perforació y voladura de roca con Fr de 45% | 6d | 2026-06-26 | 2026-07-01 | A3360 FS+5d, A1300, A1060, A1070, A1080, A1050, A3390 | 8.9d | 0d | Explotacion de cantera [5752.1]; EXCAVADORA CAT 336 [119.07 h]; TRACTOR SOBRE ORUGAS CAT D6T [22.43 h]; CAMIÓN VOLQUETE DE 20 m3 PARA ROCA [61.55 h]; MARTILLO HIDRAULICO P/EXCAVADORA [39.69 h]; ROCK DRILL 2.5" [52.92 h] |
| A3450 |  | Remoción y limpieza de material perforado y volado en cantera | 15d | 2026-07-02 | 2026-07-16 | A3430 | 8.9d | 0d |  |
| A3470 |  | Conformación de material excedente en DME | 3d | 2026-07-02 | 2026-07-04 | A3430 | 30.9d | 22d | EXCAVADORA CAT 336 [3.66 h]; TRACTOR SOBRE ORUGAS CAT D6T [23.78 h] |
| A3460 |  | Selección de material para enrocado | 7d | 2026-07-17 | 2026-07-23 | A3450 | 8.9d | 0d |  |
|  | 2 | **Carguios** |  | 2026-07-17 | 2026-07-30 |  |  |  |  |
| A3440 |  | Carguio de material inadecuado en cantera para eliminación | 8d | 2026-07-17 | 2026-07-24 | A3430, A3460 SS | 10.9d | 2d | EXCAVADORA CAT 336 [25.07 h]; CAMIÓN VOLQUETE DE 20 m3 PARA ROCA [62.53 h] |
| A3530 |  | Carguío de material seleccionado hacia zona de acopio | 9d | 2026-07-17 | 2026-07-25 | A3460 SS | 8.9d | 0d |  |
| A3420 |  | Carguio de material remanente en acopio para eliminación | 1d | 2026-07-26 | 2026-07-26 | A3530 | 8.9d | 0d | EXCAVADORA CAT 336 [1.07 h]; CAMIÓN VOLQUETE DE 20 m3 PARA ROCA [7.54 h] |
| A3480 |  | Carguío de material acopiado | 4d | 2026-07-27 | 2026-07-30 | A3430, A3440, A3420, A3470 | 8.9d | 9d | EXCAVADORA CAT 336 [32.79 h] |
|  | 6 | **IMPLEMENTACIÓN PARA CONTROL Y PESAJE DE ROCA** |  | 2026-06-26 | 2026-07-30 |  |  |  |  |
|  | 1 | **Instalación de sistema de pesaje** |  | 2026-06-26 | 2026-07-30 |  |  |  |  |
| A3490 |  | Suministro, construcción, montaje e instalación de balanza, caseta y tablero de control de pesaje | 2d | 2026-06-26 | 2026-06-27 | A3430 SS | 8.9d | 0d |  |
| A3500 |  | Operación y control de sistema de pesaje (INC Energia electrica e iluminación de plataforma de acopio y balanza) | 33d | 2026-06-28 | 2026-07-30 | A3490 | 8.9d | 9d |  |
|  | 2 | **Pruebas de control de calidad** |  | 2026-06-28 | 2026-07-30 |  |  |  |  |
| A3510 |  | Ensayos de roca | 33d | 2026-06-28 | 2026-07-30 | A3490 | 8.9d | 9d |  |
|  | 3 | **CANTERA DE CERRO TOMABAL 5** |  | 2025-06-16 | 2026-08-08 |  |  |  |  |
|  | 4 | **OBRAS PRELIMINARES** |  | 2025-06-16 | 2026-08-07 |  |  |  |  |
|  | 1 | **Construccion de acceso nuevo** |  | 2025-06-16 | 2025-07-12 |  |  |  |  |
| A2520 |  | Desbroce y remoción de suelo vegetal con equipo | 1d | 2025-06-16 | 2025-06-16 | A1270, A3990 | -0.1d | 0d | EXCAVADORA CAT 336 [1 h]; TRACTOR SOBRE ORUGAS CAT D8T [1 h] |
| A2550 |  | Excavación en material común | 10d | 2025-06-17 | 2025-06-26 | A2520 | -0.1d | 0d | EXCAVADORA CAT 336 [79.75 h]; TRACTOR SOBRE ORUGAS CAT D8T [39.88 h] |
| A2600 |  | Conformación de material excedente en DMO | 1d | 2025-06-17 | 2025-06-17 | A2520 | 14.9d | 15d |  |
| A2560 |  | Excavación en roca fracturada | 2d | 2025-06-27 | 2025-06-28 | A2550 | 287.9d | 14d | EXCAVADORA CAT 336 [7.23 h]; MARTILLO HIDRAULICO P/EXCAVADORA [7.23 h]; TRACTOR SOBRE ORUGAS CAT D8T [14.45 h] |
| A2570 |  | Excavación en roca fija con martillo hidráulico | 15d | 2025-06-27 | 2025-07-11 | A2550 | -0.1d | 0d | EXCAVADORA CAT 336 [234.57 h]; MARTILLO HIDRAULICO P/EXCAVADORA [234.57 h] |
| A2610 |  | Conformación de material excedente en DME | 6d | 2025-06-27 | 2025-07-02 | A2550 | 283.9d | 10d |  |
| A2590 |  | Proceso y selección de material propio | 8d | 2025-07-03 | 2025-07-10 | A2570 SS+6d, A2600 | -0.1d | 0d | EXCAVADORA CAT 336 [59.16 h] |
| A2580 |  | Relleno compactado con equipo pesado para accesos | 8d | 2025-07-05 | 2025-07-12 | A2590 SS+2d | -0.1d | 0d | RODILLO LISO VIBRATORIO AUTOPROPULSADO 10-12 ton [63.6 h] |

| ID | WBS | Activity | Duration | Start | Finish | Predecessors | Total float | Free float | Resources |
| --- | --- | --- | --- | --- | --- | --- | --- | --- | --- |
|  | 2 | **Conformación de plataforma para zonas de acopio** |  | 2025-07-13 | 2025-11-13 |  |  |  |  |
| A2640 |  | Desbroce y remoción de suelo vegetal con equipo | 4d | 2025-07-13 | 2025-07-16 | A2580, A2560, A2610 | 273.9d | 0d | EXCAVADORA CAT 336 [31.18 h]; TRACTOR SOBRE ORUGAS CAT D8T [31.18 h] |
| A2670 |  | Excavación en material común | 95d | 2025-07-17 | 2025-10-19 | A2640 | 273.9d | 0d | EXCAVADORA CAT 336 [779.48 h]; TRACTOR SOBRE ORUGAS CAT D8T [389.74 h] |
| A2750 |  | Conformación de material excedente en DMO | 7d | 2025-07-17 | 2025-07-23 | A2640 | 312.9d | 45d |  |
| A2730 |  | Proceso y selección de material propio | 101d | 2025-07-23 | 2025-10-31 | A2670 SS, A2710 | 267.9d | 0d |  |
| A2680 |  | Relleno compactado con equipo pesado para plataforma de acopio | 55d | 2025-09-07 | 2025-10-31 | A2670 SS+15d, A2750, A2730 FF | 267.9d | 0d | RODILLO LISO VIBRATORIO AUTOPROPULSADO 10-12 ton [1328.24 h]; TRACTOR SOBRE ORUGAS CAT D8T [1328.24 h] |
| A2760 |  | Conformación de material excedente en DME | 20d | 2025-09-30 | 2025-10-19 | A2670 FF | 289.9d | 22d |  |
| A2690 |  | Suministro, construcción e instalación de cerco perímetrico | 10d | 2025-11-01 | 2025-11-10 | A2670 FS+5d, A2680, A2790 | 267.9d | 0d |  |
| A2700 |  | Suministro, construcción e instalación de garita de control de ingreso y salida | 3d | 2025-11-11 | 2025-11-13 | A2690, A2820, A2730, A2760 | 267.9d | 268d |  |
|  | 3 | **Construcción de campamentos/oficinas** |  | 2025-07-13 | 2025-08-20 |  |  |  |  |
| A2740 |  | Desbroce y remoción de suelo vegetal con equipo | 1d | 2025-07-13 | 2025-07-13 | A2520 FS+10d, A2580 | 0.9d | 0d | EXCAVADORA CAT 336 [0.35 h]; TRACTOR SOBRE ORUGAS CAT D8T [0.35 h] |
| A2710 |  | Conformación de terraplén para campamentos | 9d | 2025-07-14 | 2025-07-22 | A2740 | 0.9d | 0d | RODILLO LISO VIBRATORIO AUTOPROPULSADO 10-12 ton [46.9 h]; EXCAVADORA CAT 336 [59.5 h]; TRACTOR SOBRE ORUGAS CAT D8T [10.5 h] |
| A2770 |  | Conformación de material excedente en DMO | 1d | 2025-07-14 | 2025-07-14 | A2740 | 8.9d | 8d |  |
| A2790 |  | Desbroce y remoción de suelo vegetal con equipo en DME | 1d | 2025-07-14 | 2025-07-14 | A2740 | 376.9d | 109d | EXCAVADORA CAT 336 [659.02 h]; TRACTOR SOBRE ORUGAS CAT D8T [659.02 h] |
| A2720 |  | Construcción de campamentos | 20d | 2025-07-23 | 2025-08-11 | A2710, A2770 | 0.9d | 0d |  |
| A2820 |  | Restauración y revegetación de áreas intervenidas | 9d | 2025-08-12 | 2025-08-20 | A2720 | 349.9d | 82d | EXCAVADORA CAT 336 [61.14 h]; TRACTOR SOBRE ORUGAS CAT D6T [74.01 h] |
|  | 4 | **Controles** |  | 2025-06-17 | 2026-08-07 |  |  |  |  |
| A4030 |  | Señalización de obra | 417d | 2025-06-17 | 2026-08-07 | A2520 | 0.9d | 1d |  |
| A4040 |  | Implementación de controles ambientales durante la construcción | 417d | 2025-06-17 | 2026-08-07 | A2520 | 0.9d | 1d |  |
| A4020 |  | Mantenimiento de campamentos | 361d | 2025-08-12 | 2026-08-07 | A2720 | 0.9d | 1d |  |
|  | 5 | **EXPLOTACION DE CANTERA** |  | 2025-07-13 | 2026-08-08 |  |  |  |  |
|  | 1 | **Habilitacion de Cantera** |  | 2025-07-13 | 2025-07-31 |  |  |  |  |
| A2830 |  | Desbroce y remoción de suelo vegetal con equipo | 2d | 2025-07-13 | 2025-07-14 | A2580 | -0.1d | 0d | EXCAVADORA CAT 336 [3.39 h]; TRACTOR SOBRE ORUGAS CAT D8T [3.39 h] |
| A2880 |  | Perforación manual y voladura (habilitación de área de perforación para Rockdrill) | 2d | 2025-07-15 | 2025-07-16 | A2830 | -0.1d | 0d | EXCAVADORA CAT 336 [5.11 h]; TRACK DRILL [14.31 h] |
| A4080 |  | Conformación de material excedente en DMO | 1d | 2025-07-15 | 2025-07-15 | A2830 | 3.9d | 4d |  |
| A2860 |  | Excavación en material suelto | 3d | 2025-07-17 | 2025-07-19 | A2880 | -0.1d | 0d | EXCAVADORA CAT 336 [16.96 h]; TRACTOR SOBRE ORUGAS CAT D8T [8.48 h] |
| A2870 |  | Excavación en roca fracturada | 12d | 2025-07-20 | 2025-07-31 | A2860, A4080 | -0.1d | 0d | EXCAVADORA CAT 336 [43.53 h]; MARTILLO HIDRAULICO P/EXCAVADORA [43.53 h]; TRACTOR SOBRE ORUGAS CAT D8T [87.06 h] |
| A2910 |  | Conformación de material excedente en DME | 11d | 2025-07-20 | 2025-07-30 | A2830 FS+5d | 0.9d | 1d | EXCAVADORA CAT 336 [8.36 h]; TRACTOR SOBRE ORUGAS CAT D6T [54.33 h] |

| ID | WBS | Activity | Duration | Start | Finish | Predecessors | Total float | Free float | Resources |
| --- | --- | --- | --- | --- | --- | --- | --- | --- | --- |
|  | 2 | **Producción material en cantera de cerro (macizo rocoso)** |  | 2025-08-01 | 2026-08-08 |  |  |  |  |
|  | 1 | **Produccion de Material** |  | 2025-08-01 | 2026-08-08 |  |  |  |  |
| A4050 |  | Perforació y voladura de roca con Fr de 45% | 373d | 2025-08-01 | 2026-08-08 | A2910, A1050, A2870 | -0.1d | 0d | Explotacion de cantera; EXCAVADORA CAT 336; TRACTOR SOBRE ORUGAS CAT D6T; CAMIÓN VOLQUETE DE 20 m3 PARA ROCA; MARTILLO HIDRAULICO P/EXCAVADORA; ROCK DRILL 2.5" |
| A4100 |  | Remoción y limpieza de material perforado y volado en cantera | 373d | 2025-08-01 | 2026-08-08 | A4050 SS | -0.1d | 0d |  |
| A3020 |  | Conformación de material excedente en DME | 370d | 2025-08-04 | 2026-08-08 | A4050 FF | -0.1d | 0d | EXCAVADORA CAT 336 [1572.1 h]; TRACTOR SOBRE ORUGAS CAT D6T [10218.6 h] |
| A4110 |  | Selección de material para enrocado | 368d | 2025-08-06 | 2026-08-08 | A4100 SS+5d | -0.1d | 0d |  |
| A2940 |  | Fracturación y selección de roca para gavión | 200d | 2025-08-13 | 2026-02-28 | A4050 SS+12d | 155.9d | 0d | EXCAVADORA CAT 336 [4042.41 h]; CAMIÓN VOLQUETE DE 20 m3 PARA ROCA [61689.8 h]; MARTILLO HIDRAULICO P/EXCAVADORA [2207.11 h] |
| A4130 |  | Selección de material para gavión | 200d | 2025-08-18 | 2026-03-05 | A2940 SS+5d | 155.9d | 156d |  |
| A2930 |  | Fracturación y selección de roca para rip rap | 5d | 2025-09-10 | 2025-09-14 | A4050 SS+6d, A2440 | 11.9d | 0d | EXCAVADORA CAT 336 [89 h]; TRACTOR SOBRE ORUGAS CAT D6T [6.94 h]; CAMIÓN VOLQUETE DE 20 m3 PARA ROCA [19.04 h]; MARTILLO HIDRAULICO P/EXCAVADORA [61.41 h] |
| A4120 |  | Selección de material para rip rap | 4d | 2025-09-15 | 2025-09-18 | A4050 SS, A2930 | 11.9d | 0d |  |
|  | 2 | **Carguios** |  | 2025-08-04 | 2026-08-08 |  |  |  |  |
| A3030 |  | Carguío de material seleccionado hacia zona de acopio | 370d | 2025-08-04 | 2026-08-08 | A4050 FF | -0.1d | 0d | EXCAVADORA CAT 336 [14087.3 h] |
| A2970 |  | Carguío de material acopiado | 365d | 2025-08-09 | 2026-08-08 | A3030 SS+5d | -0.1d | 0d |  |
| A2990 |  | Carguio de material excedente en zona de selección para eliminación | 360d | 2025-08-14 | 2026-08-08 | A4050 FF | -0.1d | 0d | EXCAVADORA CAT 336 [10769.9 h]; CAMIÓN VOLQUETE DE 20 m3 PARA ROCA [65119 h] |
| A2960 |  | Carguio de material remanente en acopio para eliminación | 50d | 2026-06-20 | 2026-08-08 | A4050 FF | -0.1d | 0d | EXCAVADORA CAT 336 [459.38 h]; CAMIÓN VOLQUETE DE 20 m3 PARA ROCA [1349.84 h] |
|  | 6 | **IMPLEMENTACIÓN PARA CONTROL Y PESAJE DE ROCA** |  | 2025-08-01 | 2026-08-07 |  |  |  |  |
|  | 1 | **Instalación de sistema de pesaje** |  | 2025-08-01 | 2026-08-07 |  |  |  |  |
| A3040 |  | Suministro, construcción, montaje e instalación de balanza, caseta y tablero de control de pesaje | 15d | 2025-08-01 | 2025-08-15 | A4050 SS | 0.9d | 0d |  |
| A3050 |  | Operación y control de sistema de pesaje (INC Energia electrica e iluminación de plataforma de acopio y balanza) | 357d | 2025-08-16 | 2026-08-07 | A3040 | 0.9d | 1d |  |
|  | 2 | **Pruebas de control de calidad** |  | 2025-08-16 | 2026-08-07 |  |  |  |  |
| A3060 |  | Ensayos de roca | 357d | 2025-08-16 | 2026-08-07 | A3040 | 0.9d | 1d |  |
|  | 4 | **CANTERA DE CAUCE - TOMABAL 4A** |  | 2025-05-12 | 2026-07-27 |  |  |  |  |
|  | 4 | **OBRAS PRELIMINARES** |  | 2025-05-12 | 2026-07-27 |  |  |  |  |
|  | 1 | **Construccion de acceso nuevo** |  | 2025-06-16 | 2025-07-26 |  |  |  |  |
| A3520 |  | Desbroce y remoción de suelo vegetal con equipo | 1d | 2025-06-16 | 2025-06-16 | A1270, A3990 | 11.9d | 0d | EXCAVADORA CAT 336 [4.82 h]; TRACTOR SOBRE ORUGAS CAT D6T [4.82 h] |
| A3540 |  | Excavación en material común | 15d | 2025-06-17 | 2025-07-01 | A3520 | 11.9d | 0d | EXCAVADORA CAT 336 [123.92 h]; TRACTOR SOBRE ORUGAS CAT D8T [61.96 h] |
| A3590 |  | Conformación de material excedente en DMO | 1d | 2025-06-17 | 2025-06-17 | A3520 | 35.9d | 24d |  |
| A3550 |  | Excavación en roca fracturada | 3d | 2025-07-02 | 2025-07-04 | A3540 | 342.9d | 22d | EXCAVADORA CAT 336 [11.23 h]; MARTILLO HIDRAULICO P/EXCAVADORA [11.23 h]; TRACTOR SOBRE ORUGAS CAT D8T [22.45 h] |
| A3560 |  | Excavación en roca fija con martillo hidráulico | 23d | 2025-07-02 | 2025-07-24 | A3540 | 11.9d | 0d | EXCAVADORA CAT 336 [364.48 h]; MARTILLO HIDRAULICO P/EXCAVADORA [364.48 h] |
| A3600 |  | Conformación de material excedente en DME | 9d | 2025-07-02 | 2025-07-10 | A3540 | 336.9d | 16d |  |
| A3580 |  | Proceso y selección de material propio | 12d | 2025-07-12 | 2025-07-23 | A3560 SS+10d, A3590 | 11.9d | 0d | EXCAVADORA CAT 336 [91.92 h] |
| A3570 |  | Relleno compactado con equipo pesado para accesos | 12d | 2025-07-15 | 2025-07-26 | A3580 SS+3d | 11.9d | 0d | RODILLO LISO VIBRATORIO AUTOPROPULSADO 10-12 ton [98.83 h] |

| ID | WBS | Activity | Duration | Start | Finish | Predecessors | Total float | Free float | Resources |
| --- | --- | --- | --- | --- | --- | --- | --- | --- | --- |
|  | 2 | **Conformación de plataforma para zonas de acopio** |  | 2025-07-27 | 2025-09-21 |  |  |  |  |
| A3630 |  | Desbroce y remoción de suelo vegetal con equipo | 2d | 2025-07-27 | 2025-07-28 | A3570, A3550, A3600 | 320.9d | 0d | EXCAVADORA CAT 336 [10.23 h]; TRACTOR SOBRE ORUGAS CAT D8T [10.23 h] |
| A3660 |  | Excavación en material común | 38d | 2025-07-29 | 2025-09-04 | A3630 | 320.9d | 0d | EXCAVADORA CAT 336 [256.65 h]; TRACTOR SOBRE ORUGAS CAT D8T [128.33 h] |
| A3780 |  | Conformación de material excedente en DMO | 3d | 2025-07-29 | 2025-07-31 | A3630 | 333.9d | 3d |  |
| A3770 |  | Proceso y selección de material propio | 34d | 2025-08-04 | 2025-09-06 | A3660 SS+6d, A3780 | 330.9d | 10d |  |
| A3670 |  | Relleno compactado con equipo pesado para plataforma de acopio | 18d | 2025-08-20 | 2025-09-06 | A3660 SS+22d | 320.9d | 0d | RODILLO LISO VIBRATORIO AUTOPROPULSADO 10-12 ton [437.34 h]; TRACTOR SOBRE ORUGAS CAT D8T [437.34 h] |
| A3880 |  | Conformación de material excedente en DME | 12d | 2025-08-24 | 2025-09-04 | A3660 FF | 332.9d | 12d |  |
| A3680 |  | Suministro, construcción e instalación de cerco perímetrico | 10d | 2025-09-07 | 2025-09-16 | A3670 | 320.9d | 0d |  |
| A3690 |  | Suministro, construcción e instalación de garita de control de ingreso y salida | 5d | 2025-09-17 | 2025-09-21 | A3680, A3770, A3880 | 320.9d | 321d |  |
|  | 3 | **Construcción de campamentos/oficinas** |  | 2025-05-12 | 2026-07-27 |  |  |  |  |
| A4150 |  | Carguío de material orgánico | 19d | 2025-05-12 | 2025-05-30 | A4210 SS | 430.9d | 74d |  |
| A3710 |  | Desbroce y remoción de suelo vegetal con equipo | 1d | 2025-07-24 | 2025-07-24 | A3580 | 11.9d | 0d |  |
| A3740 |  | Conformación de material excedente en DME | 2d | 2025-07-24 | 2025-07-25 | A3710 SS | 11.9d | 0d | EXCAVADORA CAT 336 [18.05 h]; TRACTOR SOBRE ORUGAS CAT D6T [117.34 h] |
| A3900 |  | Conformación de material excedente en DMO | 1d | 2025-07-25 | 2025-07-25 | A3710 | 374.9d | 18d |  |
| A4160 |  | Excavación en material común | 2d | 2025-07-25 | 2025-07-26 | A3710 | 36.9d | 0d |  |
| A4210 |  | Conformación de material excedente en DME y DMO | 15d | 2025-07-25 | 2025-08-08 | A3710 | 356.9d | 0d |  |
| A3700 |  | Construcción de campamentos | 18d | 2025-07-26 | 2025-08-12 | A3740 | 11.9d | 0d |  |
| A3910 |  | Conformación de terraplén para campamentos | 9d | 2025-07-27 | 2025-08-04 | A4160 | 36.9d | 0d |  |
| A3750 |  | Restauración y revegetación de áreas intervenidas | 4d | 2025-08-13 | 2025-08-16 | A3700, A3900, A3900 FF, A4150, A3910 | 356.9d | 357d | EXCAVADORA CAT 336 [24.5 h]; TRACTOR SOBRE ORUGAS CAT D6T [29.66 h] |
| A4140 |  | Mantenimiento de campamentos | 349d | 2025-08-13 | 2026-07-27 | A3700 | 11.9d | 12d |  |
|  | 4 | **Controles** |  | 2025-06-17 | 2026-07-26 |  |  |  |  |
| A3720 |  | Señalización de obra | 405d | 2025-06-17 | 2026-07-26 | A3520 | 12.9d | 13d |  |
| A3730 |  | Implementación de controles ambientales durante la construcción | 405d | 2025-06-17 | 2026-07-26 | A3520 | 12.9d | 13d |  |
|  | 5 | **EXPLOTACION DE CANTERA** |  | 2025-07-27 | 2026-07-27 |  |  |  |  |
|  | 1 | **Habilitacion de Cantera** |  | 2025-07-27 | 2025-08-22 |  |  |  |  |
| A3760 |  | Desbroce y remoción de suelo vegetal con equipo | 5d | 2025-07-27 | 2025-07-31 | A3570 | 11.9d | 0d | EXCAVADORA CAT 336 [35.86 h]; TRACTOR SOBRE ORUGAS CAT D8T [35.86 h] |
| A3810 |  | Conformación de material excedente en DMO | 5d | 2025-07-27 | 2025-07-31 | A3760 FF | 11.9d | 0d | EXCAVADORA CAT 336 [15.06 h]; TRACTOR SOBRE ORUGAS CAT D6T [97.89 h] |
| A3790 |  | Excavación en material suelto | 22d | 2025-08-01 | 2025-08-22 | A3760 | 25.9d | 0d | EXCAVADORA CAT 336 [358.57 h]; TRACTOR SOBRE ORUGAS CAT D8T [179.29 h] |
| A3800 |  | Conformación de material suelto excedente en cauce. | 22d | 2025-08-01 | 2025-08-22 | A3790 SS | 25.9d | 0d | TRACTOR SOBRE ORUGAS CAT D6T [358.57 h] |

| ID | WBS | Activity | Duration | Start | Finish | Predecessors | Total float | Free float | Resources |
| --- | --- | --- | --- | --- | --- | --- | --- | --- | --- |
|  | 2 | **Producción material en cantera de cauce (boloneria suelta)** |  | 2025-08-11 | 2026-07-27 |  |  |  |  |
|  | 4 | **Conformacion de cause** |  | 2025-08-11 | 2026-04-12 |  |  |  |  |
| A3920 |  | Excavación en material suelto | 236d | 2025-08-11 | 2026-04-03 | A3800 SS+10d, A1300, A1060, A1070, A1080, A1050 | 117.9d | 0d | EXCAVADORA CAT 336 [1922.86 h]; TRACTOR SOBRE ORUGAS CAT D8T [961.43 h] |
| A3930 |  | Conformación de material suelto excedente en cauce | 235d | 2025-08-21 | 2026-04-12 | A3920 SS+10d | 117.9d | 118d | TRACTOR SOBRE ORUGAS CAT D6T [1778.65 h] |
| A3940 |  | Conformación de material excedente en DME | 16d | 2026-03-19 | 2026-04-03 | A3920 FF | 126.9d | 127d | EXCAVADORA CAT 336 [20.19 h]; TRACTOR SOBRE ORUGAS CAT D6T [131.24 h] |
|  | 2 | **Produccion de enrocado** |  | 2025-08-23 | 2025-12-25 |  |  |  |  |
| A3820 |  | Fracturación y selección de roca con martillo hidráulico (material enrocado) | 51d | 2025-08-23 | 2025-10-12 | A3800 | 25.9d | 0d | EXCAVADORA CAT 336 [986.48 h]; TRACTOR SOBRE ORUGAS CAT D6T [85.88 h]; CAMIÓN VOLQUETE DE 20 m3 PARA ROCA [235.61 h]; MARTILLO HIDRAULICO P/EXCAVADORA [759.68 h] |
| A4170 |  | Selección de material para enrocado | 120d | 2025-08-28 | 2025-12-25 | A3820 SS+5d | 25.9d | 0d |  |
| A3840 |  | Fracturación con martillo hidráulico y trackdrill, carguío, transporte y selección de roca (material enrocado) | 23d | 2025-10-13 | 2025-11-04 | A3830 SS+15d, A3820 | 231.9d | 0d | EXCAVADORA CAT 336 [530.67 h]; TRACTOR SOBRE ORUGAS CAT D6T [85.88 h]; CAMIÓN VOLQUETE DE 20 m3 PARA ROCA [235.61 h]; MARTILLO HIDRAULICO P/EXCAVADORA [303.87 h]; TRACK DRILL [303.87 h] |
| A3860 |  | Perforación con martillo manual y voladura, carguío, transporte y selección de roca (material enrocado) | 45d | 2025-11-05 | 2025-12-19 | A3850 SS+15d, A3840 | 231.9d | 232d | EXCAVADORA CAT 336 [302.4 h]; TRACTOR SOBRE ORUGAS CAT D6T [114.5 h]; CAMIÓN VOLQUETE DE 20 m3 PARA ROCA [314.15 h]; MARTILLO NEUMATICO DE 25 - 29 kg [1820.29 h] |
|  | 1 | **Produccion de rip rap** |  | 2025-09-19 | 2026-07-22 |  |  |  |  |
| A3830 |  | Fracturación y selección de roca con martillo hidráulico (material rip rap) | 296d | 2025-09-19 | 2026-07-11 | A3820 SS+7d, A4120 | 11.9d | 0d | EXCAVADORA CAT 336 [11707.9 h]; TRACTOR SOBRE ORUGAS CAT D6T [913.22 h]; CAMIÓN VOLQUETE DE 20 m3 PARA ROCA [2505.5 h]; MARTILLO HIDRAULICO P/EXCAVADORA [8078.47 h] |
| A4180 |  | Selección de material para rip rap | 300d | 2025-09-26 | 2026-07-22 | A3830 SS+7d | 11.9d | 0d |  |
| A3850 |  | Fracturación con martillo hidráulico y trackdrill, carguío, transporte y selección de roca (material rip rap) | 267d | 2025-10-04 | 2026-06-27 | A3830 SS+15d | 41.9d | 0d | EXCAVADORA CAT 336 [6533.02 h]; TRACTOR SOBRE ORUGAS CAT D6T [913.22 h]; CAMIÓN VOLQUETE DE 20 m3 PARA ROCA [2505.5 h]; MARTILLO HIDRAULICO P/EXCAVADORA [2903.57 h]; TRACK DRILL [2903.57 h] |
| A3870 |  | Perforación con martillo manual y voladura, carguío, transporte y selección de roca (material rip rap) | 213d | 2025-10-19 | 2026-05-19 | A3850 SS+15d | 80.9d | 81d | EXCAVADORA CAT 336 [3629.46 h]; TRACTOR SOBRE ORUGAS CAT D6T [913.22 h]; CAMIÓN VOLQUETE DE 20 m3 PARA ROCA [12236.1 h]; MARTILLO NEUMATICO DE 25 - 29 kg [16110.1 h] |
|  | 3 | **Carguio** |  | 2025-08-28 | 2026-07-27 |  |  |  |  |
| A4190 |  | Carguío de Roca a zona de acopio | 320d | 2025-08-28 | 2026-07-13 | A4170 SS | 25.9d | 26d |  |
| A3950 |  | Carguío de material acopiado | 305d | 2025-09-26 | 2026-07-27 | A4180 SS | 11.9d | 0d | EXCAVADORA CAT 336 [4441.81 h] |
| A3890 |  | Carguio de material remanente en acopio para eliminación | 18d | 2026-07-10 | 2026-07-27 | A3950 FF | 11.9d | 12d | EXCAVADORA CAT 336 [144.22 h]; CAMIÓN VOLQUETE DE 20 m3 PARA ROCA [423.76 h] |
|  | 6 | **IMPLEMENTACIÓN PARA CONTROL Y PESAJE DE ROCA** |  | 2025-08-01 | 2026-07-27 |  |  |  |  |
|  | 1 | **Instalación de sistema de pesaje** |  | 2025-08-01 | 2026-07-27 |  |  |  |  |
| A3960 |  | Suministro, construcción, montaje e instalación de balanza, caseta y tablero de control de pesaje | 5d | 2025-08-01 | 2025-08-05 | A3810 | 11.9d | 0d |  |
| A3970 |  | Operación y control de sistema de pesaje (INC Energia electrica e iluminación de plataforma de acopio y balanza) | 356d | 2025-08-06 | 2026-07-27 | A3960 | 11.9d | 12d |  |
|  | 2 | **Pruebas de control de calidad** |  | 2025-08-06 | 2026-07-27 |  |  |  |  |
| A3980 |  | Ensayos de roca | 356d | 2025-08-06 | 2026-07-27 | A3960 | 11.9d | 12d |  |
